# Bridge Preservation PDN

Schedule from MS Project, 2024-06-20 to 2026-11-30, 7.5 hours a day.

## Calendars

- Standard: Mon-Fri 08:00-12:00, 13:00-16:30; Sat-Sun off. Exceptions (off unless hours are given): 2022-01-01 to 2036-01-01 (New Year's Day, recurring), 2022-01-17 to 2036-01-21 (MLK Day, recurring), 2022-02-21 to 2036-02-18 (Presidents Day, recurring), 2022-05-30 to 2036-05-26 (Memorial Day, recurring), 2022-07-04 to 2036-07-04 (Independence Day, recurring), 2022-09-05 to 2036-09-01 (Labor Day, recurring), 2022-11-11 to 2036-11-11 (Veterans Day, recurring), 2022-11-24 to 2036-11-27 (Thanksgiving, recurring), 2022-12-24 to 2036-12-24 (Christmas Eve, recurring), 2022-12-25 to 2036-12-25 (Christmas Day, recurring), 2023-06-28 to 2036-06-19 (Juneteenth, recurring), 2024-11-29 (Day after Thanksgiving (2024)), 2024-12-31 (New Year's Eve Observed (2024)), 2025-04-18 (Good Friday (2025)), 2025-11-21 to 2029-11-23 (Day after Thanksgiving, recurring), 2026-01-02 (New Year's Eve Observed (2025)), 2026-04-03 (Good Friday (2026)), 2026-07-03 (Independence Day Observed (2026)).
- Letting Calendar: Mon-Thu off; Fri 08:00-12:00, 13:00-17:00; Sat-Sun off. Exceptions (off unless hours are given): 2025-01-01 to 2025-01-31 (recurring), 2025-02-08 to 2025-03-20, 2025-03-22 to 2025-05-08, 2025-05-10 to 2025-06-26, 2025-06-28 to 2025-08-14, 2025-08-16 to 2025-10-02, 2025-10-04 to 2025-11-06, 2025-11-08 to 2025-12-04, 2025-12-06 to 2026-02-04, 2026-02-07 to 2026-03-19, 2026-03-21 to 2026-05-07, 2026-05-09 to 2026-06-25, 2026-06-27 to 2026-08-13, 2026-08-15 to 2026-10-01, 2026-10-03 to 2026-11-05, 2026-11-07 to 2026-12-03.

## Resources

| Resource |
| --- |
| Acquisition Lead - Headquarters |
| Chief Appraiser - Headquarters |
| Chief Appraiser - Region |
| Community Relations Lead |
| Construction District Lead |
| Construction Lead - Headquarters |
| Environmental Administrative Lead |
| Environmental Mitigation Lead |
| Environmental Permit Lead |
| Environmental Technical Lead |
| Environmental Technical Lead - Regions |
| Geotechnical Lead |
| Hydraulics Lead |
| ITS Lead |
| Lighting Design Lead |
| Multimodal Lead |
| Pavement Design Lead |
| Planning Lead |
| Project Development Director |
| Project Management Assistant Director |
| Regional Director |
| Regional Maintenance Lead |
| Relocation Lead Headquarters |
| Roadway Design Lead |
| ROW Lead - Headquarters |
| ROW Lead - Region |
| Signal and Lighting Design Lead |
| State Railroad Coordinator |
| STID Lead |
| Structural Design Lead |
| Structures Director |
| Survey Lead |
| Traffic Operations Lead |
| TSMO Coordinator |
| Utility Coordinator - Headquarters |
| Utility Coordinator - Region |
| Value Engineering (VE) Program Coordinator |
| TDOT Project Manager |
| Bridge Program Manager |
| Active Transportation Lea |
| Active Transportation Lead |
| TDOT Geotechnical Engineer |
| TDOT Region Roadway Designer |
| Railroad Coordinator |
| TDOT Structural Division Staff |
| TDOT Hydraulics State or Regional Staff |
| TDOT Traffic Designer |
| TBD |
| TDOT Utility Office Designee |
| Aerial Geodetics Lead |
| TDOT Geodetics |
| TDOT HQ Technical Coordinator 1 |
| Utility Coordinator |
| NEPA Lead |
| Lead Geotechnical Engineer/Geologist |
| Hydraulic Lead |
| Traffic Design Engineer |
| Regional Quality Team Lead |
| Pavement Team Lead |
| ROW Acquisition/Relocation Team Lead |
| Regional ROW Appraisal Team Lead |
| Engineering Mitigation Lead |
| Mitigation Designer |
| TDOT HQ ROW Appraisal Manager |

## Schedule

| ID | WBS | Task | Type | Duration | Start | Finish | Predecessors | Total slack | Free slack | Resources | Work |
| --- | --- | --- | --- | --- | --- | --- | --- | --- | --- | --- | --- |
| 1 | 1 | **STAGE 1- CONTEXT/SCOPING** |  | 143d | 2024-06-20 | 2025-01-17 |  | 0d |  |  | 5610h |
| 2 | 1.1 | **1PM1 Set Up Project** |  | 20d | 2024-06-20 | 2024-07-18 |  | 0d |  |  | 525h |
| 3 | 1.1.1 | 1.0 Confirm Project Assignment | milestone | 0d | 2024-06-20 | 2024-06-20 |  | 0d |  | TDOT Project Manager |  |
| 4 | 1.1.2 | **2.0 Verify Project Funding, Project Number, PIN, and Task Profile Numbers** |  | 10d | 2024-06-20 | 2024-07-03 |  | 595d |  |  | 150h |
| 5 | 1.1.2.1 | Verify Project Information |  | 10d | 2024-06-20 | 2024-07-03 | 3 | 595d |  | TDOT Project Manager | 75h |
| 6 | 1.1.2.2 | Authorize PE-NEPA Funding |  | 10d | 2024-06-20 | 2024-07-03 | 3 | 595d |  | TDOT Project Manager | 75h |
| 7 | 1.1.3 | 3.0 Request Shared Project Folder |  | 10d | 2024-06-20 | 2024-07-03 | 3 | 595d |  | TDOT Project Manager | 75h |
| 8 | 1.1.4 | 4.0 Prepare Draft Project Scope |  | 10d | 2024-06-20 | 2024-07-03 | 3 | 585d | 0d | TDOT Project Manager | 75h |
| 9 | 1.1.5 | 5.0 Prepare Preliminary Schedule |  | 10d | 2024-06-20 | 2024-07-03 | 3 | 560d | 0d | TDOT Project Manager | 75h |
| 10 | 1.1.6 | **6.0 Validate Preliminary Budget** |  | 10d | 2024-06-20 | 2024-07-03 |  | 585d |  |  | 75h |
| 11 | 1.1.6.1 | Validate Preliminary Budget |  | 10d | 2024-06-20 | 2024-07-03 | 3 | 585d | 0d | TDOT Project Manager | 75h |
| 12 | 1.1.6.2 | Confirm/Coordinate Approval of Project in the STIP/TIP | inactive | 20d | 2024-06-20 | 2024-07-18 | 3 | 585d |  | TDOT Project Manager | 150h |
| 13 | 1.1.7 | 7.0 Prepare Draft Quality Management Plan | inactive | 10d | 2024-06-20 | 2024-07-03 | 3 | 595d |  | TDOT Project Manager | 75h |
| 14 | 1.1.8 | 8.0 Prepare Draft Risk Management Plan | inactive | 20d | 2024-06-20 | 2024-07-18 | 3 | 585d |  | TDOT Project Manager | 150h |
| 15 | 1.1.9 | 9.0 Prepare Draft Project Communication Plan | inactive | 5d | 2024-06-20 | 2024-06-26 | 3 | 600d |  | TDOT Project Manager | 37.5h |
| 16 | 1.1.10 | 10.0 Prepare Draft Project Commitment Document (PCD) |  | 10d | 2024-07-05 | 2024-07-18 | 8, 9, 11 | 585d |  | TDOT Project Manager | 75h |
| 17 | 1.2 | **1PM2 Build Project Team** |  | 40d | 2024-06-20 | 2024-08-15 |  | 0d |  |  | 487.5h |
| 18 | 1.2.1 | 1.0 Identify Project Team Resources |  | 5d | 2024-06-20 | 2024-06-26 | 3 | 0d |  | TDOT Project Manager | 37.5h |
| 19 | 1.2.2 | 2.0 Build Project Team, Compile & Distribute Project Information for Desktop Reviews. |  | 20d | 2024-06-27 | 2024-07-25 | 18 | 0d |  | TDOT Project Manager | 150h |
| 20 | 1.2.3 | 3.0 Determine Type of Consultant(s) and Contract(s) Required |  | 5d | 2024-06-20 | 2024-06-26 | 3 | 565d | 0d | TDOT Project Manager | 37.5h |
| 21 | 1.2.4 | 4.0 Obtain Consultant(s) |  | 35d | 2024-06-27 | 2024-08-15 | 20 | 565d |  | TDOT Project Manager | 262.5h |
| 22 | 1.3 | **1ST1 Project Initiation** |  | 10d | 2024-06-20 | 2024-07-03 |  | 580d | 0d |  | 75h |
| 23 | 1.3.1 | 1.0 Complete Structures Division Review |  | 10d | 2024-06-20 | 2024-07-03 | 3 | 580d |  | Structural Design Lead | 75h |
| 24 | 1.4 | **1AT1 Conduct Active Transportation Review** |  | 10d | 2024-07-26 | 2024-08-08 |  | 0d |  |  | 112.5h |
| 25 | 1.4.1 | 1.0 Conduct Active Transportation Review |  | 5d | 2024-07-26 | 2024-08-01 | 19 | 5d |  | Active Transportation Lead | 37.5h |
| 26 | 1.4.2 | 2.0 Attend Site Visit | inactive | 1d | 2024-06-20 | 2024-06-20 |  | 34d |  | Active Transportation Lead | 7.5h |
| 27 | 1.4.3 | 3.0 Review the Concept Report | inactive | 10d | 2024-06-20 | 2024-07-03 |  | 25d |  | Active Transportation Lead | 75h |
| 28 | 1.4.4 | 4.0 Develop Considerations & Recommendations |  | 10d | 2024-07-26 | 2024-08-08 | 19 | 0d |  | Active Transportation Lead | 75h |

Notes:
- 3: Asset Management Office to place project on 3-year plan and Region Project Manager to Initiate Project Planning (i.e. desktop reviews and setting up project)
- 4: See Flowchart for "Bridge Preservation PDN Stage 1" in Appendix B
- 8: Coordinate with Bridge Preservation Design Lead/ Consultant - Activity 1ST1 establishes Scope.
- 9: Utilizing Appendix A
- 11: Coordinate with bridge Preservation Design Lead
- 16: Prepare Project Commitment Document using the "Bridge Preservation Project Commitment Document" in Appendix D
- 19: Coordinate with Bridge Preservation Design Lead to obtain all information necessary for team members desktop review. Prepare comment forms for team usage.
- 21: This is for the consultants contract to be completed.
- 22: For Bridge Preservation Projects, the Structural Design Lead would most likely be the Consultant working with the Bridge Preservation Office (Note for all "ST" Activities)
- 23: See Flowchart for "Structural Desktop Review" in Appendix B

| ID | WBS | Task | Type | Duration | Start | Finish | Predecessors | Total slack | Resources | Work |
| --- | --- | --- | --- | --- | --- | --- | --- | --- | --- | --- |
| 29 | 1.5 | **1EN1 Conduct Environmental Desktop Review** |  | 10d | 2024-07-26 | 2024-08-08 |  | 0d |  | 75h |
| 30 | 1.5.1 | 1.0 Identify Known Environmental Resource Information |  | 10d | 2024-07-26 | 2024-08-08 | 19 | 0d | Environmental Technical Lead | 75h |
| 31 | 1.5.2 | 2.0 Attend Site Visit | inactive | 1d | 2024-06-20 | 2024-06-20 |  | 34d | Environmental Technical Lead | 7.5h |
| 32 | 1.5.3 | 3.0 Review the Concept Report | inactive | 10d | 2024-06-20 | 2024-07-03 |  | 25d | Environmental Technical Lead | 75h |
| 33 | 1.6 | **1GT1 Conduct Geotechnical Preliminary Assessment** | inactive | 10d | 2024-06-20 | 2024-07-03 |  | 595d |  | 150h |
| 34 | 1.6.1 | 1.0 Complete Geotechnical Division Review | inactive | 10d | 2024-06-20 | 2024-07-03 |  | 595d | TDOT Geotechnical Engineer | 75h |
| 35 | 1.6.2 | 2.0 Attend Site Visit | milestone, inactive | 0d | 2024-06-20 | 2024-06-20 |  | 605d | TDOT Geotechnical Engineer |  |
| 36 | 1.6.3 | 3.0 Review the Concept Report | inactive | 10d | 2024-06-20 | 2024-07-03 |  | 595d | TDOT Geotechnical Engineer | 75h |
| 37 | 1.7 | **1RD1 Provide Roadway Desktop Review** |  | 10d | 2024-07-26 | 2024-08-08 |  | 0d |  | 75h |
| 38 | 1.7.1 | 1.0 Complete Roadway Division Review |  | 10d | 2024-07-26 | 2024-08-08 | 19 | 0d | TDOT Traffic Designer | 75h |
| 39 | 1.7.2 | 2.0 Attend Site Visit | milestone, inactive | 0d | 2024-06-20 | 2024-06-20 |  | 35d | TDOT Region Roadway Designer |  |
| 40 | 1.7.3 | 3.0 Review the Concept Report | inactive | 10d | 2024-06-20 | 2024-07-03 |  | 25d | TDOT Region Roadway Designer | 75h |
| 41 | 1.7.4 | 4.0 Complete the Design Decision Worksheet | inactive | 10d | 2024-06-20 | 2024-07-03 |  | 25d | TDOT Region Roadway Designer | 75h |
| 42 | 1.8 | **1RR1 Complete Concept-Level Railroad Review** |  | 10d | 2024-07-26 | 2024-08-08 |  | 0d |  | 75h |
| 43 | 1.8.1 | 1.0 Provide Review for Railroad in the Project Area |  | 10d | 2024-07-26 | 2024-08-08 | 19 | 0d | Railroad Coordinator | 75h |
| 44 | 1.8.2 | 2.0 Attend Site Visit | milestone, inactive | 0d | 2024-06-20 | 2024-06-20 |  | 35d | Railroad Coordinator |  |
| 45 | 1.8.3 | 3.0 Review the Concept Report | inactive | 10d | 2024-06-20 | 2024-07-03 |  | 25d | Railroad Coordinator | 75h |
| 46 | 1.9 | **1TD1 Initiate Traffic and Safety Analyses** | inactive | 10d | 2024-06-20 | 2024-07-03 |  | 595d |  | 307.5h |
| 47 | 1.9.1 | 1.0 Conduct Initial Safety Analysis | inactive | 7d | 2024-06-20 | 2024-06-28 |  | 598d | TDOT Traffic Designer | 52.5h |
| 48 | 1.9.2 | 2.0 Conduct Intersection and Interchange Evaluation (IIE) | inactive | 7d | 2024-06-20 | 2024-06-28 |  | 598d | TDOT Traffic Designer | 52.5h |
| 49 | 1.9.3 | 3.0 Alignment & Operations Review | inactive | 7d | 2024-06-20 | 2024-06-28 |  | 598d | TDOT Traffic Designer | 52.5h |
| 50 | 1.9.4 | 4.0 Attend Site Visit | milestone, inactive | 0d | 2024-06-20 | 2024-06-20 |  | 605d | TDOT Traffic Designer |  |
| 51 | 1.9.5 | 5.0 Review the Concept Report | inactive | 10d | 2024-06-20 | 2024-07-03 |  | 595d | TBD | 75h |
| 52 | 1.9.6 | 6.0 Develop RSA Generated Projects | inactive | 10d | 2024-06-20 | 2024-07-03 |  | 595d | TBD | 75h |

Notes:
- 38: Hyper focus on Traffic Control Design and the decisions needing to take place early in project for the overall design of the preservation project to work effectively.
- 43: Focused on the air-right acquisition needed, or the need for right-of way due to construction easement.

| ID | WBS | Task | Type | Duration | Start | Finish | Predecessors | Total slack | Free slack | Resources | Work |
| --- | --- | --- | --- | --- | --- | --- | --- | --- | --- | --- | --- |
| 53 | 1.10 | **1UT1 Complete Concept-Level Utility Review** |  | 10d | 2024-07-26 | 2024-08-08 |  | 0d |  |  | 75h |
| 54 | 1.10.1 | 1.0 Review Project Area for Potential Utilities |  | 10d | 2024-07-26 | 2024-08-08 | 19 | 0d |  | TDOT Utility Office Designee | 75h |
| 55 | 1.10.2 | 2.0 Attend Site Visit | milestone, inactive | 0d | 2024-06-20 | 2024-06-20 |  | 35d |  | TDOT Utility Office Designee |  |
| 56 | 1.10.3 | 3.0 Review the Concept Report | inactive | 10d | 2024-06-20 | 2024-07-03 |  | 25d |  | TDOT Utility Office Designee | 75h |
| 57 | 1.11 | **1PM3 Hold Kickoff Meeting** |  | 15d | 2024-08-09 | 2024-08-29 |  | 0d |  |  | 300h |
| 58 | 1.11.1 | 1.0 Hold Meeting |  | 5d | 2024-08-09 | 2024-08-15 | 24, 29, 37, 42, 53 | 0d |  | TDOT Project Manager | 37.5h |
| 59 | 1.11.2 | 2.0 Verify the ETSA |  | 5d | 2024-08-09 | 2024-08-15 | 30 | 565d |  | TDOT Project Manager; Environmental Technical Lead; TDOT Region Roadway Designer | 112.5h |
| 60 | 1.11.3 | 3.0 Complete Initial Construction Estimate and Finalize Scope Of Work |  | 10d | 2024-08-16 | 2024-08-29 | 58 | 555d |  | TDOT Project Manager; TDOT Structural Division Staff | 150h |
| 61 | 1.12 | **1SY1 Conduct Design-Level Survey** |  | 50d | 2024-08-16 | 2024-10-25 |  | 0d |  |  | 487.5h |
| 62 | 1.12.1 | 1.0 Request Survey from Geodetics |  | 10d | 2024-08-16 | 2024-08-29 | 58 | 0d |  | Aerial Geodetics Lead; TDOT Project Manager | 150h |
| 63 | 1.12.2 | 2.0 Complete the Aerial Survey | inactive | 25d | 2024-08-30 | 2024-10-04 | 62 | 530d |  | Aerial Geodetics Lead | 187.5h |
| 64 | 1.12.3 | 3.0 Set Control Ground Survey |  | 5d | 2024-08-30 | 2024-09-06 | 62 | 550d |  | TDOT Geodetics | 37.5h |
| 65 | 1.12.4 | 4.0 Conduct Ground Survey |  | 30d | 2024-08-30 | 2024-10-11 | 62 | 0d |  | Survey Lead | 225h |
| 66 | 1.12.5 | 5.0 Upload Survey Information into file location and Transfer Survey data to Design Team |  | 10d | 2024-10-14 | 2024-10-25 | 65 | 0d |  | Survey Lead | 75h |
| 67 | 1.13 | **1RD2 Initiate Roadway Design** |  | 53d | 2024-10-28 | 2025-01-17 |  | 0d |  |  | 472.5h |
| 68 | 1.13.1 | 1.0 Establish Project-Specific Design Criteria |  | 10d | 2024-10-28 | 2024-11-08 | 58, 66 | 455d | 0d | Roadway Design Lead | 75h |
| 69 | 1.13.2 | 2.0 Determine Work Zone Significance |  | 10d | 2024-10-28 | 2024-11-08 | 58, 66 | 0d |  | Roadway Design Lead | 75h |
| 70 | 1.13.3 | 3.0 Request Driveway Deviations | inactive | 20d | 2024-11-12 | 2024-12-11 | 71FS-40d | 485d |  | Roadway Design Lead | 150h |
| 71 | 1.13.4 | 4.0 Develop Line, Grade, and Cross Sections (Line and Grade Package) |  | 40d | 2024-11-12 | 2025-01-14 | 68 | 462d | 0d | Roadway Design Lead | 300h |
| 72 | 1.13.5 | 5.0 Compile the Line and Grade Package for Field Review |  | 3d | 2025-01-15 | 2025-01-17 | 68, 69, 71 | 462d | 0d | Roadway Design Lead | 22.5h |
| 73 | 1.14 | **1UT2 Begin Utility Coordination** |  | 70d | 2024-08-09 | 2024-11-18 |  | 465d |  |  | 525h |
| 74 | 1.14.1 | 1.0 Make Initial Utility Contact |  | 50d | 2024-08-09 | 2024-10-18 | 54 | 465d | 0d | TDOT HQ Technical Coordinator 1 | 375h |
| 75 | 1.14.2 | 2.0 Conduct Utility Coordination Kickoff Meeting |  | 5d | 2024-10-21 | 2024-10-25 | 74 | 465d | 0d | Utility Coordinator | 37.5h |
| 76 | 1.14.3 | 3.0 Prepare a Utility Estimate |  | 15d | 2024-10-28 | 2024-11-18 | 75 | 465d | 0d | Utility Coordinator | 112.5h |

Notes:
- 54: Focused on the possible need for relocation of utilities during construction. Critical Path - Make activity inactive if not required.
- 55: Critical Path - Make activity inactive if not required.
- 56: Critical Path - Make activity inactive if not required.
- 58: Could be combined with the site visit under the EC activities above (tie up logic as needed)
- 60: Consultant to complete Initial Construction Estimate after kick-off meeting and all desktop reviews in order to collect all project concept information. Turn-in to Bridge Preservation Design Lead for review, and then turned-in to Bridge Program manager and Region project Manager
- 62: Request survey through Geodetics Sharepoint App, Critical Path - Make activity inactive if not required.
- 64: Critical Path - Make activity inactive if not required.
- 65: To included picking up utilities, property information, and potentially staked ecology features (OHWM, steams, ephemerals, wetlands) amongst other standard survey items. Critical Path - Make activity inactive if not required.
- 66: Potential early task, Critical Path - Make activity inactive if not required.
- 67: For Bridge Preservation Projects, the Roadway Design Lead would most likely be the Consultant (Note for all "RD" Activities)
- 68: Could start right after the kickoff meeting or after the kickoff meeting and completion of ground survey.
- 71: VERIFY LOGIC TIES for this critical path design item. Duration depends on size of the project/complexity of design, and can be run parallel with survey, but team will likely need at least a month to tie in survey. Critical Path - Make activity inactive if not required. Only required if ROW/Haul Roads are required.
- 72: Critical Path - Make activity inactive if not required. Only required if ROW/Haul Roads are required.
- 74: Includes 60 day initial timeline + 10-day extension (50 working days). Critical Path - Make activity inactive if not required.
- 75: Critical Path - Make activity inactive if not required.
- 76: Critical Path - Make activity inactive if not required.

| ID | WBS | Task | Type | Duration | Start | Finish | Predecessors | Total slack | Free slack | Resources | Work |
| --- | --- | --- | --- | --- | --- | --- | --- | --- | --- | --- | --- |
| 77 | 1.15 | **1EN2 Complete Environmental Resource Identification** |  | 50d | 2024-08-16 | 2024-10-25 |  | 395d | 116d |  | 1837.5h |
| 78 | 1.15.1 | 1.0 Identify Historic Property Boundary(ies) and Initiate Agency Coordination |  | 45d | 2024-08-16 | 2024-10-18 | 58 | 400d |  | Environmental Technical Lead | 337.5h |
| 79 | 1.15.2 | 2.0 Identify Boundary(ies) for Potentially Eligible Archaeology Sites and Initiate Agency Coordination |  | 50d | 2024-08-16 | 2024-10-25 | 58 | 395d |  | Environmental Technical Lead | 375h |
| 80 | 1.15.3 | 3.0 Conduct Native American Coordination to Identify Consulting Parties |  | 15d | 2024-08-16 | 2024-09-06 | 58 | 430d |  | Environmental Technical Lead | 112.5h |
| 81 | 1.15.4 | **4.0 Identify Ecology Site Boundaries** |  | 40d | 2024-08-16 | 2024-10-11 |  | 405d | 0d |  | 487.5h |
| 82 | 1.15.4.1 | Develop and send shapefiles of features to design for L&G |  | 25d | 2024-08-16 | 2024-09-20 | 58 | 420d |  | Environmental Technical Lead | 187.5h |
| 83 | 1.15.4.2 | Complete an Environmental Boundaries Report (EBR) |  | 40d | 2024-08-16 | 2024-10-11 | 58 | 405d | 0d | Environmental Technical Lead | 300h |
| 84 | 1.15.5 | 5.0 Establish Air Quality Designation |  | 20d | 2024-08-16 | 2024-09-13 | 58 | 425d |  | Environmental Technical Lead | 150h |
| 85 | 1.15.6 | 6.0 Identify Potential Noise Receptor Locations |  | 30d | 2024-08-16 | 2024-09-27 | 58 | 415d |  | Environmental Technical Lead | 225h |
| 86 | 1.15.7 | 7.0 Identify Potential Hazardous Materials Sites |  | 20d | 2024-08-16 | 2024-09-13 | 58 | 425d |  | Environmental Technical Lead | 150h |
| 87 | 1.15.8 | 8.0 Identify Section 4(f) and Section 6(f) Resources | inactive | 20d | 2024-10-14 | 2024-11-08 | 81 | 385d |  | Environmental Technical Lead | 150h |
| 88 | 1.15.9 | 9.0 Analyze CSRP | inactive | 3d | 2024-10-14 | 2024-10-16 | 81 | 402d |  | Environmental Technical Lead | 22.5h |
| 89 | 1.15.10 | 10.0 Determine the NEPA Class of Action | inactive | 3d | 2024-10-14 | 2024-10-16 | 81 | 402d |  | NEPA Lead | 22.5h |
| 90 | 1.16 | **1GT2 Develop Geotechnical Work Plan** | inactive | 20d | 2024-08-16 | 2024-09-13 |  | 545d |  |  | 150h |
| 91 | 1.16.1 | 1.0 Gather Relevant Geotechnical Information | inactive | 5d | 2024-08-16 | 2024-08-22 | 58 | 545d | 0d | Lead Geotechnical Engineer/Geologist | 37.5h |
| 92 | 1.16.2 | 2.0 Conduct Initial Field Visit (if needed) | inactive | 5d | 2024-08-23 | 2024-08-29 | 91 | 545d | 0d | Lead Geotechnical Engineer/Geologist | 37.5h |
| 93 | 1.16.3 | 3.0 Identify Project Type and Potential Mitigation Strategies | inactive | 5d | 2024-08-30 | 2024-09-06 | 92 | 545d | 0d | Lead Geotechnical Engineer/Geologist | 37.5h |
| 94 | 1.16.4 | 4.0 Develop Geotechnical Work Plan | inactive | 5d | 2024-09-09 | 2024-09-13 | 93 | 545d |  | Lead Geotechnical Engineer/Geologist | 37.5h |
| 95 | 1.17 | **1ST2 Complete Existing and No Structure Modeling** | inactive | 20d | 2024-08-16 | 2024-09-13 |  | 545d |  |  | 150h |
| 96 | 1.17.1 | 1.0 Hydraulically Model Existing and No Structure Conditions | inactive | 20d | 2024-08-16 | 2024-09-13 | 58 | 545d |  | Hydraulic Lead | 150h |
| 97 | 1.18 | **1TD2 Conduct Traffic Analysis, Warrants, and Significance Determination** | inactive | 40d | 2024-08-16 | 2024-10-11 |  | 525d |  |  | 825h |
| 98 | 1.18.1 | 1.0 Complete the Traffic Operations Analysis | inactive | 40d | 2024-08-16 | 2024-10-11 | 58 | 525d |  | Traffic Design Engineer | 300h |
| 99 | 1.18.2 | 2.0 Complete the Traffic Safety Evaluation | inactive | 15d | 2024-08-16 | 2024-09-06 | 58 | 550d |  | Traffic Design Engineer | 112.5h |
| 100 | 1.18.3 | 3.0 Analyze Signal Warrants | inactive | 15d | 2024-08-16 | 2024-09-06 | 58 | 525d | 0d | Traffic Design Engineer | 112.5h |
| 101 | 1.18.4 | 4.0 Analyze Lighting Warrants | inactive | 15d | 2024-08-16 | 2024-09-06 | 58 | 525d | 0d | Traffic Design Engineer | 112.5h |
| 102 | 1.18.5 | 5.0 Prepare Signal, Lighting, and ITS Scope and Estimate | inactive | 10d | 2024-09-09 | 2024-09-20 | 100, 101 | 525d | 0d | Traffic Design Engineer | 75h |
| 103 | 1.18.6 | 6.0 Complete Systems Engineering Analysis | inactive | 5d | 2024-09-23 | 2024-09-27 | 102 | 525d | 0d | Traffic Design Engineer | 37.5h |
| 104 | 1.18.7 | 7.0 Determine Work Zone Significance | inactive | 10d | 2024-09-30 | 2024-10-11 | 103 | 525d |  | Roadway Design Lead | 75h |

Notes:
- 82: Recommend the data collection/field survey work for ecology be done ASAP in Stage 1 (while survey is modelized in 1SY1), so that the shapefiles can be incorporated into the Line and Grade Package before finalizing. If the shapefiles are available prior to
- 89: Typically a TEER is needed vs a NEPA permit.
- 94: Logic could be simplified depending scope of the geotech work
- 103: If needed
- 104: May delete, but coordinate with similar 1RD1 task

| ID | WBS | Task | Type | Duration | Start | Finish | Predecessors | Baseline start | Baseline finish | Baseline duration | Total slack | Free slack | Resources | Work |
| --- | --- | --- | --- | --- | --- | --- | --- | --- | --- | --- | --- | --- | --- | --- |
| 105 | 1.19 | **1RR2 Begin Railroad Coordination** |  | 50d | 2024-08-16 | 2024-10-25 |  |  |  |  | 340d |  |  | 487.5h |
| 106 | 1.19.1 | 1.0 Initiate Railroad Coordination |  | 50d | 2024-08-16 | 2024-10-25 | 58 |  |  |  | 515d |  | Railroad Coordinator | 375h |
| 107 | 1.19.2 | 2.0 Prepare Railroad Cost Estimate |  | 15d | 2024-08-16 | 2024-09-06 | 58 |  |  |  | 340d | 0d | Railroad Coordinator | 112.5h |
| 108 | 1.20 | **1PM5 Hold Scoping Meeting and L&G Field Review** | inactive | 40d | 2025-01-21 | 2025-03-18 |  |  |  |  | 422d |  |  | 412.5h |
| 109 | 1.20.1 | 1.0 Review Period (Complete Comment Form) | inactive | 15d | 2025-01-21 | 2025-02-10 | 72 |  |  |  | 422d | 0d | TDOT Project Manager | 112.5h |
| 110 | 1.20.2 | 2.0 Quality Assurance Evaluation | inactive | 15d | 2025-02-11 | 2025-03-04 | 109 |  |  |  | 432d |  | Regional Quality Team Lead | 112.5h |
| 111 | 1.20.3 | 3.0 Compile Comments and Hold Meeting | inactive | 5d | 2025-02-11 | 2025-02-18 | 109 | 2022-07-07 | 2022-07-20 | 10.67d | 422d | 0d | TDOT Project Manager | 37.5h |
| 112 | 1.20.4 | 4.0 Estimate the Project Using the Line and Grade Package | inactive | 15d | 2025-02-19 | 2025-03-11 | 111 |  |  |  | 422d | 0d | TDOT Project Manager | 112.5h |
| 113 | 1.20.5 | 5.0 Determine Need for Value Engineering | inactive | 5d | 2025-03-12 | 2025-03-18 | 109, 112 |  |  |  | 422d |  | TDOT Project Manager | 37.5h |
| 114 | 2 | Stage 1 Complete | milestone | 0d | 2024-10-11 | 2024-10-11 | 83, 58 |  |  |  | 525d | 0d |  |  |
| 115 | 3 | **STAGE 2- FOOTPRINT ESTABLISHED** |  | 318d | 2024-07-05 | 2025-10-14 |  |  |  |  | 90d |  |  | 5010h |
| 116 | 3.1 | **2PM1 Manage Project** |  | 318d | 2024-07-05 | 2025-10-14 |  |  |  |  | 277d |  |  | 712.5h |
| 117 | 3.1.1 | **1.0 Develop Project Management Plan** | inactive | 220d | 2024-06-20 | 2025-05-09 |  |  |  |  | 385d |  |  | 262.5h |
| 118 | 3.1.1.1 | Develop PMP | inactive | 20d | 2024-06-20 | 2024-07-18 |  |  |  |  | 585d |  | TDOT Project Manager | 150h |
| 119 | 3.1.1.2 | PMP Update 1 | inactive | 10d | 2024-06-20 | 2024-07-03 |  |  |  |  | 595d |  | TDOT Project Manager | 75h |
| 120 | 3.1.1.3 | PMP Update 2 | inactive | 5d | 2025-05-05 | 2025-05-09 | 140 |  |  |  | 385d |  | TDOT Project Manager | 37.5h |
| 121 | 3.1.2 | **2.0 Report Project Status** | inactive | 5d | 2024-06-20 | 2024-06-26 |  |  |  |  | 600d |  |  | 75h |
| 122 | 3.1.2.1 | Status Update 1 | inactive | 5d | 2024-06-20 | 2024-06-26 |  |  |  |  | 600d |  | TDOT Project Manager | 37.5h |
| 123 | 3.1.2.2 | Status Update 2 | inactive | 5d | 2024-06-20 | 2024-06-26 |  |  |  |  | 600d |  | TDOT Project Manager | 37.5h |
| 124 | 3.1.3 | **3.0 Finalize Local Government Agreements** | inactive | 80d | 2024-06-20 | 2024-10-11 |  |  |  |  | 525d |  |  | 750h |
| 125 | 3.1.3.1 | Enter Agreement 1 Name | inactive | 80d | 2024-06-20 | 2024-10-11 |  |  |  |  | 525d |  | TDOT Project Manager | 600h |
| 126 | 3.1.3.2 | Enter Agreement 2 Name | inactive | 20d | 2024-06-20 | 2024-07-18 |  |  |  |  | 585d |  | TDOT Project Manager | 150h |
| 127 | 3.1.4 | **4.0 Perform Letting Readiness Assessment** | inactive | 10d | 2024-06-20 | 2024-07-03 |  |  |  |  | 595d |  |  | 187.5h |
| 128 | 3.1.4.1 | Functional Design Plans | inactive | 10d | 2024-06-20 | 2024-07-03 |  |  |  |  | 595d |  | TDOT Project Manager | 75h |
| 129 | 3.1.4.2 | Plan-in-Hand | inactive | 10d | 2024-06-20 | 2024-07-03 |  |  |  |  | 595d |  | TDOT Project Manager | 75h |
| 130 | 3.1.4.3 | Construction Documents | inactive | 5d | 2024-06-20 | 2024-06-26 |  |  |  |  | 600d |  | TDOT Project Manager | 37.5h |
| 131 | 3.1.5 | 5.0 Support Value Engineering Efforts |  | 50d | 2024-11-12 | 2025-01-29 | 68 |  |  |  | 455d |  | TDOT Project Manager | 375h |
| 132 | 3.1.6 | 6.0 Manage Consultant Contracts and Modifications | milestone | 0d | 2024-10-11 | 2024-10-11 | 114 |  |  |  | 525d |  | TDOT Project Manager |  |

Notes:
- 106: Critical Path - Make activity inactive if not required.
- 107: Critical Path - Make activity inactive if not required.
- 108: This could serve as the Line and Grade field review, but the scoping meeting can also be completed earlier in Stage 1 (as a separate meeting).
- 111: Confirm scope, schedule, budget
- 117: This activity also covers 3PM1 and 4PM1
- 122: Tie up based on occurrence/need
- 123: Tie up based on occurrence/need
- 125: Check duration and logic for each project
- 126: Need to tie up if additional agreements are needed
- 132: Runs the length of the project; could be inactivated for each project

| ID | WBS | Task | Type | Duration | Start | Finish | Predecessors | Total slack | Free slack | Resources | Work |
| --- | --- | --- | --- | --- | --- | --- | --- | --- | --- | --- | --- |
| 133 | 3.1.7 | **7.0 Request and Obtain Authorization of Funds** |  | 318d | 2024-07-05 | 2025-10-14 |  | 277d |  |  | 337.5h |
| 134 | 3.1.7.1 | Authorize PE-Design Funding |  | 15d | 2024-07-05 | 2024-07-25 | 22 | 580d |  | TDOT Project Manager | 112.5h |
| 135 | 3.1.7.2 | Authorize ROW/Utility/RR Funding |  | 15d | 2025-05-05 | 2025-05-23 | 140, 207 | 375d |  | TDOT Project Manager | 112.5h |
| 136 | 3.1.7.3 | Authorize Construction Funding |  | 15d | 2025-09-24 | 2025-10-14 | 310 | 277d |  | TDOT Project Manager | 112.5h |
| 137 | 3.2 | **2PM2 Complete Project Commitment Document (PCD)** |  | 20d | 2025-04-04 | 2025-05-02 |  | 375d |  |  | 225h |
| 138 | 3.2.1 | 1.0 Verify Schedule |  | 10d | 2025-04-04 | 2025-04-17 | 9, 168, 211 | 375d | 0d | TDOT Project Manager | 75h |
| 139 | 3.2.2 | 2.0 Verify Estimates |  | 10d | 2025-04-04 | 2025-04-17 | 167, 76 | 375d | 0d | TDOT Project Manager | 75h |
| 140 | 3.2.3 | 3.0 Finalize Project Commitment Document (PCD) |  | 10d | 2025-04-21 | 2025-05-02 | 138, 139, 158 | 375d | 0d | TDOT Project Manager | 75h |
| 141 | 3.3 | **2SY1 Complete SUE and Requested Staking** | inactive | 55d | 2024-06-20 | 2024-09-06 |  | 110d |  |  | 375h |
| 142 | 3.3.1 | 1.0 Incorporate SUE Level A and B Request into Survey | inactive | 40d | 2024-07-12 | 2024-09-06 | 146 | 95d | 0d | Survey Lead | 300h |
| 143 | 3.3.2 | 2.0 Stake Sounding Holes | inactive | 10d | 2024-06-20 | 2024-07-03 |  | 595d |  | Survey Lead | 75h |
| 144 | 3.4 | **2RD1 Develop Functional Design Plans** |  | 75d | 2024-11-12 | 2025-03-06 |  | 0d |  |  | 1012.5h |
| 145 | 3.4.1 | 1.0 Develop a Utility Impact/Conflict Matrix | inactive | 15d | 2024-06-20 | 2024-07-11 |  | 590d |  | Roadway Design Lead | 112.5h |
| 146 | 3.4.2 | 2.0 Identify Initial Subsurface Utility Engineering (SUE) Needs | inactive | 15d | 2024-06-20 | 2024-07-11 |  | 95d | 0d | Roadway Design Lead | 112.5h |
| 147 | 3.4.3 | **3.0 Request Pavement Design** | inactive | 10d | 2024-06-20 | 2024-07-03 |  | 150d |  |  | 82.5h |
| 148 | 3.4.3.1 | Request pavement design | inactive | 1d | 2024-06-20 | 2024-06-20 |  | 604d |  | Roadway Design Lead | 7.5h |
| 149 | 3.4.3.2 | Receive and incorporate pavement design | inactive | 10d | 2024-06-20 | 2024-07-03 |  | 150d |  | Roadway Design Lead | 75h |
| 150 | 3.4.4 | 4.0 Document Design Exceptions and Waivers |  | 5d | 2024-11-12 | 2024-11-18 | 69 | 55d |  | Roadway Design Lead | 37.5h |
| 151 | 3.4.5 | 5.0 Incorporate SUE Data and Lead Internal Design Deconfliction Meeting | inactive | 10d | 2024-09-09 | 2024-09-20 | 142 | 95d |  | Roadway Design Lead | 75h |
| 152 | 3.4.6 | 6.0 Develop Utility Coordination Plans |  | 5d | 2024-11-12 | 2024-11-18 | 69 | 500d |  | Roadway Design Lead | 37.5h |
| 153 | 3.4.7 | 7.0 Develop Design and Sketches for Permit Applications |  | 30d | 2024-11-12 | 2024-12-27 | 69 | 475d |  | Roadway Design Lead | 225h |
| 154 | 3.4.8 | 8.0 Develop Conceptual Traffic Control Strategies |  | 20d | 2024-11-12 | 2024-12-11 | 69 | 40d |  | Roadway Design Lead | 150h |
| 155 | 3.4.9 | 9.0 Develop the Functional Design Plans |  | 60d | 2024-11-12 | 2025-02-12 | 69 | 0d |  | Roadway Design Lead | 450h |
| 156 | 3.4.10 | 10.0 Coordinate Geotechnical Analysis for Noise and Retaining Walls | inactive | 10d | 2024-06-20 | 2024-07-03 |  | 595d |  | Roadway Design Lead | 75h |
| 157 | 3.4.11 | 11.0 Compile the Functional Design Plans and Participate in the Field Review |  | 5d | 2025-02-13 | 2025-02-20 | 149, 150, 151, 154, 155 | 0d |  | Roadway Design Lead | 37.5h |
| 158 | 3.4.12 | 12.0 Revise and Submit Updated Functional Design Plans |  | 10d | 2025-02-21 | 2025-03-06 | 157 | 0d |  | Roadway Design Lead | 75h |

Notes:
- 133: These authorizations can also be split up, but regardless need to be confirmed prior to request.
- 135: Critical Path - Make activity inactive if not required.
- 136: Need design estimate to request authorization, but at the end of the process
- 145: Or use related line under 2UT1
- 151: See related line under 2UT1 for both the Utility Coordinator and Roadway Lead to coordinate this step
- 152: This could begin in Stage 2 or early Stage 3. Consider advancing at risk if the project is under an accelerated schedule.
- 155: Duration depends on size of the project/complexity of design.

| ID | WBS | Task | Type | Duration | Start | Finish | Predecessors | Total slack | Free slack | Resources | Work |
| --- | --- | --- | --- | --- | --- | --- | --- | --- | --- | --- | --- |
| 159 | 3.5 | **2RD2 Conduct Design Public Meeting** | inactive | 66d | 2024-06-20 | 2024-09-23 |  | 539d |  |  | 495h |
| 160 | 3.5.1 | 1.0 Prepare for the Design Public Meeting | inactive | 55d | 2024-06-20 | 2024-09-06 |  | 539d | 0d | Roadway Design Lead | 412.5h |
| 161 | 3.5.2 | 2.0 Hold Design Public Meeting | inactive | 1d | 2024-09-09 | 2024-09-09 | 160 | 539d | 0d | Roadway Design Lead | 7.5h |
| 162 | 3.5.3 | 3.0 Process Design Public Meeting Transcript | inactive | 10d | 2024-09-10 | 2024-09-23 | 161 | 539d |  | Roadway Design Lead | 75h |
| 163 | 3.6 | **2PV1 Provide Pavement Design** | inactive | 10d | 2024-06-20 | 2024-07-03 |  | 595d |  |  | 75h |
| 164 | 3.6.1 | 1.0 Provide Pavement Design | inactive | 10d | 2024-06-20 | 2024-07-03 |  | 595d |  | Pavement Team Lead | 75h |
| 165 | 3.7 | **2RW1 Initiate Pre-Acquisition Activities** |  | 60d | 2025-03-07 | 2025-06-02 |  | 319d |  |  | 825h |
| 166 | 3.7.1 | 1.0 Prepare CSRP | inactive | 15d | 2024-06-20 | 2024-07-11 |  | 590d |  | ROW Acquisition/Relocation Team Lead | 112.5h |
| 167 | 3.7.2 | 2.0 Prepare Right-of-Way Estimate |  | 20d | 2025-03-07 | 2025-04-03 | 158 | 375d | 0d | Regional ROW Appraisal Team Lead | 150h |
| 168 | 3.7.3 | 3.0 Perform Title Searches |  | 20d | 2025-03-07 | 2025-04-03 | 158 | 319d | 0d | ROW Acquisition/Relocation Team Lead | 150h |
| 169 | 3.7.4 | 4.0 Initiate Private Property Owner Utility Adjustment |  | 40d | 2025-04-04 | 2025-06-02 | 168 | 370d |  | ROW Acquisition/Relocation Team Lead | 300h |
| 170 | 3.7.5 | 5.0 Initiate PGI Field Work |  | 30d | 2025-04-04 | 2025-05-16 | 168 | 319d | 0d | ROW Acquisition/Relocation Team Lead | 225h |
| 171 | 3.8 | **2PM3 Conduct ROW Strategy Meeting(s)** | inactive | 40d | 2024-06-20 | 2024-08-15 |  | 565d |  |  | 307.5h |
| 172 | 3.8.1 | 2.0 Hold Meeting and Document/Distribute Minutes | inactive | 40d | 2024-06-20 | 2024-08-15 |  | 565d |  | TDOT Project Manager | 300h |
| 173 | 3.8.2 | 3.0 Attend ROW Site Visit and Collect Feedback | inactive | 1d | 2024-06-20 | 2024-06-20 |  | 604d |  | TDOT Project Manager | 7.5h |
| 174 | 3.9 | **2RW2 Execute ROW Proposal** |  | 61d | 2025-05-19 | 2025-08-14 |  | 319d |  |  | 457.5h |
| 175 | 3.9.1 | 1.0 Prepare/Submit ROW Proposal |  | 1d | 2025-05-19 | 2025-05-19 | 170 | 319d | 0d | ROW Acquisition/Relocation Team Lead | 7.5h |
| 176 | 3.9.2 | 2.0 Receive ROW Proposal and Distribute for Execution |  | 60d | 2025-05-20 | 2025-08-14 | 175 | 319d |  | ROW Acquisition/Relocation Team Lead | 450h |
| 177 | 3.10 | **2UT1 Initiate Utility Pre-Acquisition Activities** |  | 15d | 2025-03-07 | 2025-03-27 |  | 415d |  |  | 112.5h |
| 178 | 3.10.1 | 1.0 Coordinate/Request Needed SUE | inactive | 5d | 2024-06-20 | 2024-06-26 |  | 600d |  | Utility Coordinator | 37.5h |
| 179 | 3.10.2 | 2.0 Confirm Utility Estimate |  | 15d | 2025-03-07 | 2025-03-27 | 76, 158 | 415d |  | Utility Coordinator | 112.5h |
| 180 | 3.10.3 | 3.0 Develop a Utility Impact/Conflict Matrix | inactive | 15d | 2024-11-19 | 2024-12-11 | 76 | 485d |  | Utility Coordinator | 112.5h |
| 181 | 3.10.4 | 4.0 Review SUE Data and Attend Internal Design Deconfliction Meeting | inactive | 10d | 2024-06-20 | 2024-07-03 |  | 595d |  | Utility Coordinator | 75h |
| 182 | 3.11 | **2GT1 Complete the Soils and Geology Report** | inactive | 12d | 2024-06-20 | 2024-07-08 |  | 593d |  |  | 105h |
| 183 | 3.11.1 | 1.0 Conduct Site Exploration for Soils and Geology Report | inactive | 1d | 2024-06-20 | 2024-06-20 |  | 602d | 9d | Lead Geotechnical Engineer/Geologist | 7.5h |
| 184 | 3.11.2 | 2.0 Select the Appropriate Laboratory Testing Program | inactive | 10d | 2024-06-20 | 2024-07-03 |  | 593d | 0d | Lead Geotechnical Engineer/Geologist | 75h |
| 185 | 3.11.3 | 3.0 Develop the Soils and Geology Report | inactive | 1d | 2024-07-05 | 2024-07-05 | 183, 184 | 593d | 0d | Lead Geotechnical Engineer/Geologist | 7.5h |
| 186 | 3.11.4 | 4.0 Develop Associated Geotechnical Sheet (G-Sheets) | inactive | 1d | 2024-07-08 | 2024-07-08 | 185 | 593d |  | Lead Geotechnical Engineer/Geologist | 7.5h |
| 187 | 3.11.5 | 5.0 Develop Supporting Project Addenda | inactive | 1d | 2024-06-20 | 2024-06-20 |  | 604d |  | Lead Geotechnical Engineer/Geologist | 7.5h |

Notes:
- 160: Public meeting requests need to be submitted 8 weeks before the public meeting to CRD. Public Hearing requests must be submitted to CRD with this checklist ten (10) weeks in advance of hearing date.
- 167: Critical Path - Make activity inactive if not required.
- 168: Critical Path - Make activity inactive if not required.
- 169: Critical Path - Make activity inactive if not required.
- 170: Critical Path - Make activity inactive if not required.
- 172: Meant to either manage meeting-by-meeting or over the course of the meetings
- 173: Various (as many as needed); tie up logic accordingly
- 175: Critical Path - Make activity inactive if not required.
- 176: Critical Path - Make activity inactive if not required.
- 178: Coordinate with 2RD1 Task 2.0
- 179: Critical Path - Make activity inactive if not required. This is mainly in order to request ROW funding if required.
- 180: Or use related line under 2RD1
- 181: See related line under 2RD1 for both the Utility Coordinator and Roadway Lead to coordinate this step
- 187: Tie up logic if needed

| ID | WBS | Task | Type | Duration | Start | Finish | Predecessors | Total slack | Free slack | Resources | Work |
| --- | --- | --- | --- | --- | --- | --- | --- | --- | --- | --- | --- |
| 188 | 3.12 | **2GT2 Complete Foundation Reports** | inactive | 90d | 2024-06-20 | 2024-10-25 |  | 515d |  |  | 840h |
| 189 | 3.12.1 | 1.0 Conduct Site Exploration for Structures | inactive | 60d | 2024-06-20 | 2024-09-13 |  | 515d | 0d | Lead Geotechnical Engineer/Geologist | 450h |
| 190 | 3.12.2 | 2.0 Complete and Submit Foundation Report for Retaining Wall(s) | inactive | 30d | 2024-09-16 | 2024-10-25 | 189 | 515d |  | Lead Geotechnical Engineer/Geologist | 225h |
| 191 | 3.12.3 | 3.0 Complete and Submit Foundation Report for Noise Wall(s) | inactive | 1d | 2024-09-16 | 2024-09-16 | 189 | 544d |  | Lead Geotechnical Engineer/Geologist | 7.5h |
| 192 | 3.12.4 | 4.0 Complete and Submit Standard Report for Signs, Lighting, Signals, ITS, and High-Mast Lighting | inactive | 20d | 2024-09-16 | 2024-10-11 | 189 | 525d |  | Lead Geotechnical Engineer/Geologist | 150h |
| 193 | 3.12.5 | 5.0 Complete and Submit Foundation Report for Bridges | inactive | 1d | 2024-09-16 | 2024-09-16 | 189 | 544d |  | Lead Geotechnical Engineer/Geologist | 7.5h |
| 194 | 3.13 | **2ST1 Complete Hydraulic Design** | inactive | 60d | 2024-06-20 | 2024-09-13 |  | 545d |  |  | 787.5h |
| 195 | 3.13.1 | 1.0 Verify Proposed Grade and Estimate Hydraulic Structure Sizes | inactive | 15d | 2024-06-20 | 2024-07-11 |  | 545d | 0d | Hydraulic Lead | 112.5h |
| 196 | 3.13.2 | 2.0 Develop Draft Hydraulic Layout | inactive | 25d | 2024-07-12 | 2024-08-15 | 195 | 545d | 0d | Hydraulic Lead | 187.5h |
| 197 | 3.13.3 | 3.0 Hydraulically Model Proposed Conditions, Evaluate Proposals, and Select Appropriate Structure | inactive | 25d | 2024-07-12 | 2024-08-15 | 195 | 545d | 0d | Hydraulic Lead | 187.5h |
| 198 | 3.13.4 | 4.0 Finalize Hydraulic Layout | inactive | 20d | 2024-08-16 | 2024-09-13 | 196, 197 | 545d |  | Hydraulic Lead | 150h |
| 199 | 3.13.5 | 5.0 Finalize Hydraulic Design Information | inactive | 20d | 2024-08-16 | 2024-09-13 | 196, 197 | 545d |  | Hydraulic Lead | 150h |
| 200 | 3.14 | **2ST2 Develop Preliminary Bridge Plans** |  | 40d | 2024-11-12 | 2025-01-14 |  | 465d |  |  | 300h |
| 201 | 3.14.1 | 1.0 Review Proposed Grade and Alignment for Non-Hydraulic Crossings | inactive | 15d | 2024-06-20 | 2024-07-11 |  | 590d |  | Structural Design Lead | 112.5h |
| 202 | 3.14.2 | 2.0 Develop Preliminary Bridge Layouts |  | 40d | 2024-11-12 | 2025-01-14 | 69 | 465d |  | Structural Design Lead | 300h |
| 203 | 3.14.3 | 3.0 Coordinate Geotechnical Analysis for Bridges | inactive | 5d | 2024-06-20 | 2024-06-26 |  | 600d |  | Structural Design Lead | 37.5h |
| 204 | 3.15 | **2EN2 Complete Environmental Document** |  | 45d | 2024-10-14 | 2024-12-18 |  | 465d |  |  | 337.5h |
| 205 | 3.15.1 | 1.0 Review/Finalize Purpose and Need Statement |  | 10d | 2024-10-14 | 2024-10-25 | 83 | 465d | 0d | NEPA Lead | 75h |
| 206 | 3.15.2 | 2.0 Complete Environmental Document |  | 20d | 2024-10-28 | 2024-11-25 | 205 | 465d | 0d | NEPA Lead | 150h |
| 207 | 3.15.3 | 3.0 Receive Approval (as applicable) |  | 15d | 2024-11-26 | 2024-12-18 | 206 | 465d | 90d | NEPA Lead | 112.5h |
| 208 | 3.15.4 | 4.0 Functional Design Plans Review (if needed): Complete Environmental Document Re-Evaluation | inactive | 15d | 2025-03-07 | 2025-03-27 | 158 | 415d |  | NEPA Lead | 112.5h |
| 209 | 3.15.5 | 5.0 Plan-in-Hand Review: Complete Environmental Document Re-Evaluation | inactive | 15d | 2025-04-28 | 2025-05-16 | 239 | 380d |  | NEPA Lead | 112.5h |
| 210 | 3.16 | **2EN3 Conduct Permit Assessment** |  | 36d | 2025-03-07 | 2025-04-28 |  | 255d |  |  | 382.5h |
| 211 | 3.16.1 | 1.0 Complete Permit Assessment |  | 15d | 2025-03-07 | 2025-03-27 | 158 | 255d | 0d | Environmental Permit Lead | 112.5h |
| 212 | 3.16.2 | 2.0 Finalize Plans and Sketch Review and Prepare Permittable Plans Package |  | 1d | 2025-03-28 | 2025-03-28 | 211 | 394d | 0d | Environmental Permit Lead | 7.5h |
| 213 | 3.16.3 | 3.0 Evaluate Permittable Plans Package |  | 15d | 2025-03-31 | 2025-04-21 | 212 | 394d | 0d | Environmental Permit Lead | 112.5h |
| 214 | 3.16.4 | 4.0 Review EPSC Plans in the Functional Design Plans |  | 15d | 2025-03-07 | 2025-03-27 | 158 | 410d | 16d | Environmental Permit Lead | 112.5h |
| 215 | 3.16.5 | 5.0 Lead Pre-application meeting with USACE and TDEC |  | 5d | 2025-04-22 | 2025-04-28 | 211, 212, 213, 214 | 394d |  | Environmental Permit Lead | 37.5h |

Notes:
- 192: See PDN; this is likely going to just entail getting the borings and holding them for contractor reference; typically no formal report is needed for signal, signs, and lighting (with the exception of high-mast).
- 202: Note: Once Preliminary Bridge Preservation Plans have been completed, the Bridge Preservation Office is responsible for the quality control of the plans (both roadway plan set - delegated if necessary, and structures plans)
- 205: Typically a TEER document needed for state funded projects.
- 206: Typically a TEER document needed for state funded projects.
- 207: Duration assumes FHWA approval of NEPA document; if TEER this can be shorter (~15 days)
- 208: This could be 3 weeks to 6 months depending on impacts/changes in design. This activity is optional depending on if the environmental document is complete at the time the plans are submitted for review.
- 209: This could be 3 weeks to 6 months depending on impacts/changes in design.
- 212: Adjust duration based on complexity of permit impacts.
- 214: Procure six weeks prior to Functional Plan turn-in
- 215: Optional task that will help in coordinating with USACE and TDEC on the project details and upcoming permit application and content.

| ID | WBS | Task | Type | Duration | Start | Finish | Predecessors | Total slack | Free slack | Resources | Work |
| --- | --- | --- | --- | --- | --- | --- | --- | --- | --- | --- | --- |
| 216 | 3.17 | **2PM4 Conduct Permit Strategy Meeting(s)** |  | 65d | 2025-04-22 | 2025-07-24 |  | 334d |  |  | 45h |
| 217 | 3.17.1 | 1.0 Hold Meeting |  | 5d | 2025-04-22 | 2025-04-28 | 58, 77, 213, 214 | 394d |  | TDOT Project Manager | 37.5h |
| 218 | 3.17.2 | 2.0 Verify Permit(s) Are Complete and Submitted |  | 1d | 2025-07-24 | 2025-07-24 | 305 | 334d |  | TDOT Project Manager | 7.5h |
| 219 | 3.18 | **2EN4 Complete Mitigation Assessment and Initiate Mitigation Design** |  | 40d | 2024-10-14 | 2024-12-11 |  | 455d |  |  | 412.5h |
| 220 | 3.18.1 | **1.0 Complete Mitigation Assessment** |  | 30d | 2024-10-14 | 2024-11-25 |  | 455d | 0d |  | 337.5h |
| 221 | 3.18.1.1 | Complete Mitigation Assessment |  | 15d | 2024-10-14 | 2024-11-01 | 81 | 470d |  | Engineering Mitigation Lead | 112.5h |
| 222 | 3.18.1.2 | Evaluate mitigation (Bank or In-Lieu fee) availability and permittee responsibilities |  | 15d | 2024-10-14 | 2024-11-01 | 81 | 455d | 0d | Engineering Mitigation Lead | 112.5h |
| 223 | 3.18.1.3 | - Identify Need for Concurrent Project |  | 15d | 2024-11-04 | 2024-11-25 | 222 | 455d |  | Engineering Mitigation Lead | 112.5h |
| 224 | 3.18.2 | 2.0 Develop Preliminary Mitigation Plan (30% designed) |  | 10d | 2024-11-26 | 2024-12-11 | 220 | 455d | 45d | Mitigation Designer | 75h |
| 225 | 3.19 | **2TD1 Prepare ITS, Signals, and Lighting Sheets** | inactive | 1d | 2024-06-20 | 2024-06-20 |  | 604d |  |  | 30h |
| 226 | 3.19.1 | 1.0 Prepare ITS Sheets | inactive | 1d | 2024-06-20 | 2024-06-20 |  | 604d |  | Traffic Design Engineer | 7.5h |
| 227 | 3.19.2 | 2.0 Prepare Signal Sheets | inactive | 1d | 2024-06-20 | 2024-06-20 |  | 604d |  | Traffic Design Engineer | 7.5h |
| 228 | 3.19.3 | 3.0 Prepare Lighting Sheets | inactive | 1d | 2024-06-20 | 2024-06-20 |  | 604d |  | Traffic Design Engineer | 7.5h |
| 229 | 3.19.4 | 4.0 Oversee Development of the Conceptual Traffic Control Strategies | inactive | 1d | 2024-06-20 | 2024-06-20 |  | 604d |  | Traffic Design Engineer | 7.5h |
| 230 | 3.20 | **2PM5 Hold Functional Design Plans Field Review Meeting** |  | 15d | 2025-03-07 | 2025-03-27 |  | 330d |  |  | 187.5h |
| 231 | 3.20.1 | 1.0 Review Period (Complete Comment Form) |  | 10d | 2025-03-07 | 2025-03-20 | 158 | 330d | 0d | TDOT Project Manager | 75h |
| 232 | 3.20.2 | 2.0 Quality Assurance Evaluation |  | 10d | 2025-03-07 | 2025-03-20 | 158 | 420d |  | Regional Quality Team Lead | 75h |
| 233 | 3.20.3 | 3.0 Compile Comments, Hold Meeting, and Document/Distribute Minutes |  | 5d | 2025-03-21 | 2025-03-27 | 231 | 330d | 0d | TDOT Project Manager | 37.5h |
| 234 | 4 | Stage 2 Complete | milestone | 0d | 2025-03-06 | 2025-03-06 | 158 | 430d |  |  |  |
| 235 | 5 | **STAGE 3- PLAN-IN-HAND** |  | 550d | 2024-09-09 | 2026-11-30 |  | 0d |  |  | 11692.5h |
| 236 | 5.1 | **3RD1 Complete Plan-in-Hand Design** |  | 25d | 2025-03-28 | 2025-05-02 |  | 330d |  |  | 487.5h |
| 237 | 5.1.1 | 1.0 Develop ROW Acquisition Exhibits |  | 20d | 2025-04-04 | 2025-05-02 | 168 | 390d |  | Roadway Design Lead | 150h |
| 238 | 5.1.2 | 2.0 Finalize the TMP & Complete the Temporary Traffic Control Plans |  | 20d | 2025-03-28 | 2025-04-25 | 233 | 330d | 0d | Roadway Design Lead | 150h |
| 239 | 5.1.3 | 3.0 Complete Plan-in-Hand Plans |  | 20d | 2025-03-28 | 2025-04-25 | 233 | 330d | 0d | Roadway Design Lead | 150h |
| 240 | 5.1.4 | 4.0 Compile the Plan-in-Hand Plans and Participate in the Field Review |  | 5d | 2025-04-28 | 2025-05-02 | 238, 239 | 330d | 0d | Roadway Design Lead | 37.5h |

Notes:
- 217: Meant to either manage meeting-by-meeting or over the course of the meetings
- 218: Various (as many as needed)
- 219: Critical Path - Make activity inactive if not required.
- 222: If needed based on impacts determined from the assessment
- 223: If needed (meaning TDOT is not using credits/bank)
- 224: If needed (meaning TDOT is not using credits/bank)
- 237: This could begin in Stage 2 or early Stage 3. Consider advancing at risk if the project is under an accelerated schedule. Crticial Path Activity, make row inactive if not used.
- 239: Duration depends on size of the project/complexity of design, and can be run parallel with survey at risk.

| ID | WBS | Task | Type | Duration | Start | Finish | Predecessors | Total slack | Free slack | Resources | Work |
| --- | --- | --- | --- | --- | --- | --- | --- | --- | --- | --- | --- |
| 241 | 5.2 | **3UT1 Perform Utility Coordination** |  | 129d | 2025-03-07 | 2025-09-10 |  | 201d |  |  | 1155h |
| 242 | 5.2.1 | 1.0 Distribute Utility Coordination Plans |  | 5d | 2025-03-07 | 2025-03-13 | 158 | 201d | 0d | Utility Coordinator | 37.5h |
| 243 | 5.2.2 | 2.0 Conduct Utility Plan Review Kickoff Meeting |  | 2d | 2025-04-11 | 2025-04-14 | 244 | 403d |  | Utility Coordinator | 15h |
| 244 | 5.2.3 | 3.0 Approve Engineering Packages |  | 20d | 2025-03-14 | 2025-04-10 | 242 | 403d | 0d | Utility Coordinator | 150h |
| 245 | 5.2.4 | 4.0 Complete 120-day Utility Review and Process Relocation Contract Requests |  | 84d | 2025-03-14 | 2025-07-15 | 242 | 201d | 0d | Utility Coordinator | 630h |
| 246 | 5.2.5 | 5.0 Submit Rainbows to Environmental | inactive | 5d | 2025-07-16 | 2025-07-22 | 245 | 336d |  | Utility Coordinator | 37.5h |
| 247 | 5.2.6 | **6.0 Put Utilities to Work** |  | 40d | 2025-07-16 | 2025-09-10 |  | 301d |  |  | 300h |
| 248 | 5.2.6.1 | Generate and Execute Relocation Contract |  | 25d | 2025-07-16 | 2025-08-19 | 245 | 301d | 0d | Utility Coordinator | 187.5h |
| 249 | 5.2.6.2 | Send PTW Letter |  | 10d | 2025-08-20 | 2025-09-03 | 248 | 301d | 0d | Utility Coordinator | 75h |
| 250 | 5.2.6.3 | Utility Advances Its Work |  | 5d | 2025-09-04 | 2025-09-10 | 249 | 301d |  | Utility Coordinator | 37.5h |
| 251 | 5.2.7 | 7.0 Submit Construction Drawings to Design |  | 3d | 2025-07-16 | 2025-07-18 | 245 | 328d | 17d | Utility Coordinator | 22.5h |
| 252 | 5.3 | **3UT2 Prepare and Submit Utility Certification** |  | 30d | 2025-07-16 | 2025-08-26 |  | 311d |  |  | 225h |
| 253 | 5.3.1 | 1.0 Receive and Process Utility Deposits |  | 20d | 2025-07-16 | 2025-08-12 | 245 | 311d | 0d | Utility Coordinator | 150h |
| 254 | 5.3.2 | 2.0 Verify Utility Coordination is Complete |  | 10d | 2025-08-13 | 2025-08-26 | 251, 253 | 311d |  | Utility Coordinator | 75h |
| 255 | 5.4 | **3EN1 Finalize Stream & Wetland Mitigation Design** |  | 30d | 2025-02-21 | 2025-04-03 |  | 410d |  |  | 225h |
| 256 | 5.4.1 | 1.0 Finalize Mitigation Plans |  | 30d | 2025-02-21 | 2025-04-03 | 157, 224 | 410d |  | Mitigation Designer | 225h |
| 257 | 5.5 | **3EN2 Complete Environmental Permit Applications and Obtain Permits** |  | 214d | 2025-03-28 | 2026-02-09 |  | 201d |  |  | 2250h |
| 258 | 5.5.1 | 1.0 Complete Aquatic Permit Application (for the roadway project) |  | 40d | 2025-03-28 | 2025-05-23 | 77FF, 211 | 255d | 0d | Environmental Permit Lead | 300h |
| 259 | 5.5.2 | 2.0 Obtain Aquatic Resource Permits |  | 120d | 2025-05-27 | 2025-11-14 | 258 | 255d |  | Environmental Permit Lead | 900h |
| 260 | 5.5.3 | 3.0 Modify or Complete Aquatic Permit Application (for Utility Relocation Impacts) |  | 20d | 2025-07-16 | 2025-08-12 | 245 | 201d | 0d | Environmental Permit Lead | 150h |
| 261 | 5.5.4 | 4.0 Obtain Aquatic Resource Permits (for utilities) |  | 120d | 2025-08-13 | 2026-02-09 | 260 | 201d |  | Environmental Permit Lead | 900h |
| 262 | 5.6 | **4EN1 Complete and Obtain Stormwater Permit** |  | 60d | 2025-05-05 | 2025-07-30 |  | 330d |  |  | 450h |
| 263 | 5.6.1 | 1.0 Complete Stormwater Permit Application |  | 30d | 2025-05-05 | 2025-06-16 | 290FS-15d | 330d | 0d | Environmental Permit Lead | 225h |
| 264 | 5.6.2 | 2.0 Obtain NPDES Coverage |  | 30d | 2025-06-17 | 2025-07-30 | 263 | 330d |  | Environmental Permit Lead | 225h |

Notes:
- 242: Critical Path - Make activity inactive if not required. This could also tie to Compile Functional Design Plans at the latest (see 2RD1, task 11.0); see PDN for what to show on the plans (namely permittable features as no relocation areas)
- 243: Critical Path - Make activity inactive if not required.
- 244: Critical Path - Make activity inactive if not required.
- 245: Critical Path - Make activity inactive if not required.
- 246: Note that this could be the plans for PIH submittal if the u-sheet (task 8.0) are not available yet
- 248: Critical Path - Make activity inactive if not required.
- 249: Critical Path - Make activity inactive if not required.
- 250: Length dependent on in-state contract vs. utility self-performed work.Critical Path - Make activity inactive if not required.
- 251: Critical Path - Make activity inactive if not required. Typically tied to the utilities b-date package and can either be 26 weeks prior to letting or 60 days after receiving the a-date package (at then end of task 4.0 above).
- 253: Critical Path - Make activity inactive if not required.
- 254: Critical Path - Make activity inactive if not required.
- 255: Critical Path - Make activity inactive if not required.
- 256: Critical Path - Make activity inactive if not required.
- 258: Confirm tie to certain env. tech studies or the environmental document
- 259: Duration based on permit type determined under 2EN2. This duration could be 120 days to 18 months depending on what permit is needed and if a off-site mitigation site is needed....
- 260: Note the tie to receiving response from utility owners regarding relocation of their facilities. This is a late tie, notably if the relocation is going to impact a feature. This tie may drive a lag in the schedule that can be mitigated with early utility coordination and a clear depiction of where the utility cannot go on the Utility Coordination Plans (or Functional Design Plans). Critical Path - Make Activity Inactive if not required
- 261: Work with Permitting on mitigating this risk, which could considerably extend the schedule depending on utility impacts to features. This risk can be mitigated with early coordination and working with utilities to understand where they can and cannot move. Critical Path - Make Activity Inactive if not required
- 263: As soon as the ESCPs are available; application must include stamped cover sheet

| ID | WBS | Task | Type | Duration | Start | Finish | Predecessors | Total slack | Free slack | Resources | Work |
| --- | --- | --- | --- | --- | --- | --- | --- | --- | --- | --- | --- |
| 265 | 5.7 | **3ST1 Complete Structural Design** |  | 20d | 2025-03-28 | 2025-04-25 |  | 395d |  |  | 150h |
| 266 | 5.7.1 | 1.0 Complete Retaining/Noise Wall Sheets | inactive | 1d | 2024-06-20 | 2024-06-20 |  | 604d |  | Structural Design Lead | 7.5h |
| 267 | 5.7.2 | 2.0 Complete Design and Detail Bridge Plans and Estimate |  | 20d | 2025-03-28 | 2025-04-25 | 233 | 395d |  | Structural Design Lead | 150h |
| 268 | 5.8 | **3RW1 Complete Appraisal and Initiate Acquisition** |  | 150d | 2025-03-07 | 2025-10-09 |  | 0d |  |  | 1425h |
| 269 | 5.8.1 | 1.0 Produce Preliminary Group Inspection (PGI) Report |  | 30d | 2025-03-07 | 2025-04-17 | 158 | 0d |  | Regional ROW Appraisal Team Lead | 225h |
| 270 | 5.8.2 | 2.0 Employ Fee Appraiser |  | 60d | 2025-04-21 | 2025-07-16 | 269 | 0d |  | TDOT HQ ROW Appraisal Manager | 450h |
| 271 | 5.8.3 | 3.0 Stake ROW |  | 20d | 2025-04-21 | 2025-05-16 | 269 | 40d |  | ROW Acquisition/Relocation Team Lead | 150h |
| 272 | 5.8.4 | 4.0 Appraise Property |  | 60d | 2025-07-17 | 2025-10-09 | 270, 271 | 0d |  | ROW Acquisition/Relocation Team Lead | 450h |
| 273 | 5.8.5 | 5.0 Review Appraisals |  | 20d | 2025-08-21 | 2025-09-18 | 272SS+25d | 0d |  | ROW Acquisition/Relocation Team Lead | 150h |
| 274 | 5.9 | **3RW2 Prepare and Submit ROW Certification** |  | 285d | 2025-10-03 | 2026-11-30 |  | 0d |  |  | 3487.5h |
| 275 | 5.9.1 | 1.0 Perform/Finish Acquiring Property |  | 180d | 2025-10-03 | 2026-06-29 | 273SS+30d | 100d |  | ROW Acquisition/Relocation Team Lead | 1350h |
| 276 | 5.9.2 | 2.0 Perform/Finish ROW Relocation |  | 280d | 2025-10-03 | 2026-11-19 | 273SS+30d | 0d |  | ROW Acquisition/Relocation Team Lead | 2100h |
| 277 | 5.9.3 | 3.0 Review ROW Acquisition Process, Verify/Update Schedule, and Issue ROW Certification |  | 5d | 2026-11-20 | 2026-11-30 | 275, 276 | 0d |  | ROW Acquisition/Relocation Team Lead | 37.5h |
| 278 | 5.10 | **3TD1 Complete Signal, Lighting, and ITS Device Design** |  | 10d | 2025-04-28 | 2025-05-09 |  | 385d |  |  | 75h |
| 279 | 5.10.1 | 1.0 Complete Signal Design | inactive | 1d | 2024-06-20 | 2024-06-20 |  | 604d |  | Traffic Design Engineer | 7.5h |
| 280 | 5.10.2 | 2.0 Complete Lighting Design | inactive | 1d | 2024-06-20 | 2024-06-20 |  | 604d |  | Traffic Design Engineer | 7.5h |
| 281 | 5.10.3 | 3.0 Complete ITS Device Design | inactive | 1d | 2024-06-20 | 2024-06-20 |  | 604d |  | Traffic Design Engineer | 7.5h |
| 282 | 5.10.4 | 4.0 Review the TMP for Compliance |  | 10d | 2025-04-28 | 2025-05-09 | 238 | 385d |  | Traffic Design Engineer | 75h |
| 283 | 5.11 | **3RR1 Perform Railroad Coordination** |  | 180d | 2024-09-09 | 2025-06-02 |  | 340d |  |  | 1350h |
| 284 | 5.11.1 | 1.0 Receive Railroad Plans and Estimates |  | 180d | 2024-09-09 | 2025-06-02 | 107 | 340d | 0d | Railroad Coordinator | 1350h |
| 285 | 5.12 | **3RR2 Prepare and Submit Railroad Certification** |  | 30d | 2025-06-03 | 2025-07-16 |  | 340d |  |  | 225h |
| 286 | 5.12.1 | 1.0 Finalize the Railroad Agreement(s) |  | 30d | 2025-06-03 | 2025-07-16 | 284 | 340d |  | Railroad Coordinator | 225h |
| 287 | 5.13 | **3PM2 Hold Plan-in-Hand Field Review Meeting** |  | 15d | 2025-05-05 | 2025-05-23 |  | 330d |  |  | 187.5h |
| 288 | 5.13.1 | 1.0 Review Period (Complete Comment Form) |  | 10d | 2025-05-05 | 2025-05-16 | 240 | 330d | 0d | TDOT Project Manager | 75h |
| 289 | 5.13.2 | 2.0 Quality Assurance Evaluation |  | 10d | 2025-05-05 | 2025-05-16 | 240 | 380d |  | Regional Quality Team Lead | 75h |
| 290 | 5.13.3 | 3.0 Compile Comments and Hold Meeting |  | 5d | 2025-05-19 | 2025-05-23 | 288 | 330d | 0d | TDOT Project Manager | 37.5h |
| 291 | 5.14 | Stage 3 Complete | milestone | 0d | 2025-05-23 | 2025-05-23 | 290 | 375d |  |  |  |

Notes:
- 267: Note: Once Final Bridge Preservation Plans have been completed, the Bridge Preservation Office is responsible for the quality control of the plans (both roadway plan set - delegated if necessary, and structures plans)
- 269: Critical Path - Make activity inactive if not required.
- 270: Critical Path - Make activity inactive if not required.
- 271: Critical Path - Make activity inactive if not required.
- 272: Critical Path - Make activity inactive if not required.
- 273: Critical Path - Make activity inactive if not required.
- 275: Critical Path - Make activity inactive if not required.
- 276: Critical Path - Make activity inactive if not required. Not typically included in bridge repair projects.
- 277: Critical Path - Make activity inactive if not required.
- 284: Critical Path - Make activity inactive if not required.
- 286: Certification of Railroad Agreement. Critical Path - Make activity inactive if not required.

| ID | WBS | Task | Type | Duration | Start | Finish | Predecessors | Total slack | Free slack | Constraint | Calendar | Resources | Work |
| --- | --- | --- | --- | --- | --- | --- | --- | --- | --- | --- | --- | --- | --- |
| 292 | 6 | **STAGE 4- PS&E** |  | 40d | 2025-05-27 | 2025-07-23 |  | 334d |  |  |  |  | 450h |
| 293 | 6.1 | **4RD1 Finalize Construction Documents** |  | 25d | 2025-05-27 | 2025-07-01 |  | 334d |  |  |  |  | 187.5h |
| 294 | 6.1.1 | 1.0 Finalize the Roadway Plans for the PS&E Review Meeting |  | 20d | 2025-05-27 | 2025-06-24 | 290 | 334d | 0d |  |  | Roadway Design Lead | 150h |
| 295 | 6.1.2 | 2.0 Compile the Final Construction Documents |  | 5d | 2025-06-25 | 2025-07-01 | 294, 297, 298, 300, 301 | 334d | 0d |  |  | Roadway Design Lead | 37.5h |
| 296 | 6.2 | **4GT1 Finalize Geotech Plans** | inactive | 20d | 2024-06-20 | 2024-07-18 |  | 564d |  |  |  |  | 300h |
| 297 | 6.2.1 | 1.0 Finalize Geotechnical Design Documents | inactive | 20d | 2024-06-20 | 2024-07-18 |  | 564d | 230d |  |  | Lead Geotechnical Engineer/Geologist | 150h |
| 298 | 6.2.2 | 2.0 Finalize Geotechnical Special Provisions for Letting | inactive | 20d | 2024-06-20 | 2024-07-18 |  | 564d | 230d |  |  | Lead Geotechnical Engineer/Geologist | 150h |
| 299 | 6.3 | **4ST1 Finalize Structural Plans** |  | 20d | 2025-05-27 | 2025-06-24 |  | 334d |  |  |  |  | 150h |
| 300 | 6.3.1 | 1.0 Finalize Retaining/Noise Wall Plans | inactive | 20d | 2024-06-20 | 2024-07-18 |  | 564d | 230d |  |  | Structural Design Lead | 150h |
| 301 | 6.3.2 | 2.0 Finalize Bridge Plans |  | 20d | 2025-05-27 | 2025-06-24 | 290 | 334d | 0d |  |  | Structural Design Lead | 150h |
| 302 | 6.4 | **4TD1 Finalize Signal, Lighting, and ITS Plans** | inactive | 20d | 2024-06-20 | 2024-07-18 |  | 585d |  |  |  |  | 300h |
| 303 | 6.4.1 | 1.0 Finalize Related Design Documents | inactive | 20d | 2024-06-20 | 2024-07-18 |  | 585d |  |  |  | Traffic Design Engineer | 150h |
| 304 | 6.4.2 | 2.0 Finalize ITS Special Provisions | inactive | 20d | 2024-06-20 | 2024-07-18 |  | 585d |  |  |  | Traffic Design Engineer | 150h |
| 305 | 6.5 | **4PM2 Hold PS&E Review Meeting** |  | 15d | 2025-07-02 | 2025-07-23 |  | 334d | 0d |  |  |  | 112.5h |
| 306 | 6.5.1 | 1.0 Review Period (Complete Comment Form) |  | 5d | 2025-07-02 | 2025-07-09 | 295 | 334d | 0d |  |  | TDOT Project Manager | 37.5h |
| 307 | 6.5.2 | 2.0 Compile Comments and Hold Meeting |  | 5d | 2025-07-10 | 2025-07-16 | 306 | 334d | 0d |  |  | TDOT Project Manager | 37.5h |
| 308 | 6.5.3 | 3.0 Finalize Project Documentation |  | 5d | 2025-07-17 | 2025-07-23 | 307 | 334d |  |  |  | TDOT Project Manager | 37.5h |
| 309 | 7 | Deadline to turn into the QA team | milestone | 0d | 2025-09-10 | 2025-09-10 | 313SS-86ed | 302d |  |  |  | Regional Quality Team Lead |  |
| 310 | 8 | Construction Document Turn-in | milestone | 0d | 2025-09-24 | 2025-09-24 | 313SS-72ed | 277d | 0d |  |  |  |  |
| 311 | 9 | Stage 4 Complete | milestone | 0d | 2025-09-24 | 2025-09-24 | 310 | 292d |  |  |  |  |  |
| 312 | 10 | Advertise Contract | milestone | 0d | 2025-11-07 | 2025-11-07 | 313SS-28ed | 260d |  |  |  |  |  |
| 313 | 11 | Project Letting | milestone | 0d | 2025-12-05 | 2025-12-05 |  | 7.47d | 0d | start no earlier than 2025-12-05 | Letting Calendar |  |  |

Notes:
- 301: Note: Once Final Bridge Preservation Plans have been completed, the Bridge Preservation Office is responsible for the quality control of the plans (both roadway plan set - delegated if necessary, and structures plans)
- 309: Final deliverable review
